# TemplateCronogramaPRO.NET

Schedule from MS Project, 2003-06-09 to 2003-09-02, A marks actual dates.
Qualiti

## Calendars

- Standard: Mon-Fri 08:00-12:00, 13:00-17:00; Sat-Sun off.

## Resources

| Resource |
| --- |
| Alessandro |
| Suzana |
| Andre |
| Adeline |
| Gustavo |

## Schedule

| ID | WBS | Task | Duration | Start | Finish | Predecessors | Complete | Remaining | Total slack | Free slack | Constraint | Resources | Work | Actual work |
| --- | --- | --- | --- | --- | --- | --- | --- | --- | --- | --- | --- | --- | --- | --- |
| 1 | 1 | **Q.METRIC C#** | 61.62d | 2003-06-09 08:00 A | 2003-09-02 14:00 |  | 28% | 44.45d | 0.75d |  |  |  | 261.5h | 72.9h |
| 2 | 1.1 | **Desenvolvimento** | 60.62d | 2003-06-09 08:00 A | 2003-09-01 14:00 |  | 31% | 41.53d | 1.75d |  |  |  | 231.5h | 72.9h |
| 3 | 1.1.1 | **Internal Release 0.1.0** | 3.12d | 2003-08-18 08:00 A | 2003-08-21 09:00 |  | 48% | 1.64d | 8.5d |  |  |  | 46.5h | 22.1h |
| 4 | 1.1.1.1 | Terminar parser básico | 4h | 2003-08-18 08:00 A | 2003-08-18 12:00 A |  | 100% |  |  |  | start no earlier than 2003-08-18 08:00 | Adeline | 4h | 4h |
| 5 | 1.1.1.2 | Terminar métricas básicas | 2h | 2003-08-18 08:00 A | 2003-08-18 10:00 A |  | 100% |  |  |  | start no earlier than 2003-08-18 08:00 | Gustavo | 2h | 2h |
| 6 | 1.1.1.3 | Classes de interface (parser + métricas básicas) | 2h | 2003-08-18 10:00 A | 2003-08-18 12:00 A | 5 | 100% |  |  |  | start no earlier than 2003-06-18 08:00 | Gustavo | 2h | 2h |
| 7 | 1.1.1.4 | Terminar GUI | 2.5h | 2003-08-18 08:00 A | 2003-08-18 10:30 |  | 20% | 2h | 11.21d | 0d | start no earlier than 2003-08-18 08:00 | Andre | 2.5h | 0.5h |
| 8 | 1.1.1.5 | Infraestrutura para ASP.NET - (*) | 8h | 2003-08-18 08:00 A | 2003-08-18 17:00 A |  | 100% |  |  |  | start no earlier than 2003-08-18 08:00 | Suzana | 8h | 8h |
| 9 | 1.1.1.6 | **Testes Internal Release 0.1.0** | 2.81d | 2003-08-18 10:30 A | 2003-08-21 09:00 |  | 20% | 2.25d | 8.5d |  |  |  | 28h | 5.6h |
| 10 | 1.1.1.6.1 | Concluir Plano de Testes | 1h | 2003-08-18 10:30 A | 2003-08-18 11:30 | 7 | 20% | 0.8h | 11.19d |  | start no earlier than 2003-06-18 08:00 | Andre | 1h | 0.2h |
| 11 | 1.1.1.6.2 | Projeto de Testes | 3h | 2003-08-18 11:30 A | 2003-08-19 08:30 A | 10 | 100% |  |  |  |  | Andre | 3h | 3h |
| 12 | 1.1.1.6.3 | Execução dos Testes básicos | 2h | 2003-08-19 08:00 A | 2003-08-19 10:00 A | 8, 5, 4 | 100% |  |  |  |  | Suzana | 2h | 2h |
| 13 | 1.1.1.6.4 | Gerar build do primeiro release | 1h | 2003-08-19 10:00 | 2003-08-19 11:00 | 12 |  |  | 0.25d | 0d |  | Andre | 1h |  |
| 14 | 1.1.1.6.5 | Execução dos Testes | 2h | 2003-08-19 11:00 A | 2003-08-19 13:00 | 13 | 20% | 1.6h | 3.12d | 0.75d |  | Andre | 2h | 0.4h |
| 15 | 1.1.1.6.6 | Ajustes Adeline | 5h | 2003-08-19 11:00 | 2003-08-20 10:00 | 13, 4 |  |  | 2.88d | 0d |  | Adeline | 5h |  |
| 16 | 1.1.1.6.7 | Ajustes André | 5h | 2003-08-20 10:00 | 2003-08-21 09:00 | 14, 15 |  |  | 2.38d |  |  | Andre | 5h |  |
| 17 | 1.1.1.6.8 | Ajustes Gustavo | 5h | 2003-08-18 12:00 | 2003-08-19 11:00 | 6 |  |  | 10.25d |  |  | Gustavo | 5h |  |
| 18 | 1.1.1.6.9 | Ajustes Suzana | 4h | 2003-08-19 11:00 | 2003-08-19 16:00 | 13, 8 |  |  | 0.25d | 0d |  | Suzana | 4h |  |
| 19 | 1.1.2 | **Internal Release 0.2.0** | 57.38d | 2003-06-09 08:00 A | 2003-08-27 11:00 |  | 43% | 32.46d | 5d |  |  |  | 117h | 50.8h |
| 20 | 1.1.2.1 | Descrever Documento do Internal Release | 4h | 2003-08-19 16:00 A | 2003-08-20 11:00 A | 18 | 100% |  |  |  | start no earlier than 2003-06-18 08:00 | Suzana | 4h | 4h |
| 21 | 1.1.2.2 | **Finalizar Parser e classes de interface** | 4.25d | 2003-08-20 10:00 | 2003-08-26 12:00 |  |  |  | 0.75d |  |  |  | 26h |  |
| 22 | 1.1.2.2.1 | Classes de interface (parser + métricas OO e complexidade) | 4h | 2003-08-20 10:00 | 2003-08-20 14:00 | 15 |  |  | 2.88d | 0.38d |  | Adeline | 4h |  |
| 23 | 1.1.2.2.2 | Codificação | 10h | 2003-08-21 08:00 | 2003-08-22 12:00 | 22 |  |  | 2.5d | 0d |  | Adeline | 10h |  |
| 24 | 1.1.2.2.3 | Testes de Unidade | 2h | 2003-08-22 12:00 | 2003-08-22 14:00 | 23 |  |  | 2.88d | 0.38d |  | Adeline | 2h |  |

Notes:
- 7: O que falta a ser feito: / 1) Conseguir inserir um arquivo em uma solucao ASP.NET Web Application programaticamente. A aplicacao esta' travando quando se tenta realizar isso. / 2) Terminar a internacionalizacao. Como o escopo esta' sendo muito alterado, nao internacionalizei tudo para nao ter o trabalho de refazer depois.
- 10: A conclusao do Plano de Testes tem como pendencia a conclusao do escopo. Como este nao foi fechado, o Plano de Testes para os ultimos releases nao foi feito, para que o trabalho nao seja perdido ou precise ser refeito.
- 13: Esta atividade só será realizada quando os testes do primeiro release passarem.
- 14: Como o critério de aceitação para os testes deste primeiro release exigem que 100% dos testes passem, e bugs ainda existem, mais testes vão ser necessários no futuro.
- 18: Ainda não foram terminados os testes do release

| ID | WBS | Task | Duration | Start | Finish | Predecessors | Complete | Remaining | Total slack | Free slack | Resources | Work | Actual work |
| --- | --- | --- | --- | --- | --- | --- | --- | --- | --- | --- | --- | --- | --- |
| 25 | 1.1.2.2.4 | **Métricas Básica de ASP.NET** | 1.5d | 2003-08-25 08:00 | 2003-08-26 12:00 |  |  |  | 0.5d |  |  | 10h |  |
| 26 | 1.1.2.2.4.1 | Codificação (parser + métricas) | 8h | 2003-08-25 08:00 | 2003-08-26 10:00 | 24 |  |  | 2.5d | 0d | Adeline | 8h |  |
| 27 | 1.1.2.2.4.2 | Testes de Unitários | 2h | 2003-08-26 10:00 | 2003-08-26 12:00 | 26 |  |  | 5.88d |  | Adeline | 2h |  |
| 28 | 1.1.2.3 | **Métricas Complexidade** | 52.5d | 2003-06-09 08:00 A | 2003-08-20 13:00 |  | 50% | 26.25d | 9.88d |  |  | 12h | 6h |
| 29 | 1.1.2.3.1 | **Codificação** | 1.12d | 2003-08-19 11:00 A | 2003-08-20 13:00 |  | 75% | 0.28d | 9.12d |  |  | 8h | 6h |
| 30 | 1.1.2.3.1.1 | [RF009] Determinar profundidade do maior aninhamento de loops | 1.5h | 2003-08-19 11:00 A | 2003-08-19 12:30 A | 17 | 100% |  |  |  | Gustavo | 1.5h | 1.5h |
| 31 | 1.1.2.3.1.2 | [RF010] Determinar profundidade do maior aninhamento condicional | 1.5h | 2003-08-19 12:30 A | 2003-08-19 14:00 A | 30 | 100% |  |  |  | Gustavo | 1.5h | 1.5h |
| 32 | 1.1.2.3.1.3 | [RF011] Determinar a posição do maior aninhamento de loops | 1h | 2003-08-20 08:00 | 2003-08-20 09:00 | 31 |  |  | 9.38d | 0d | Gustavo | 1h |  |
| 33 | 1.1.2.3.1.4 | [RF012] Determinar a posição do maior aninhamento condicional | 1h | 2003-08-20 09:00 | 2003-08-20 10:00 | 32 |  |  | 9.38d |  | Gustavo | 1h |  |
| 34 | 1.1.2.3.1.5 | [RF013] Calcular NCSS | 3h | 2003-08-20 10:00 A | 2003-08-20 13:00 A | 33 | 100% |  |  |  | Gustavo | 3h | 3h |
| 35 | 1.1.2.3.2 | Teste de Unidade | 4h | 2003-06-09 08:00 | 2003-06-09 12:00 |  |  |  | 61.5d |  | Gustavo | 4h |  |
| 36 | 1.1.2.4 | **Visualização dos resultados** | 2.88d | 2003-08-20 13:00 A | 2003-08-25 11:00 |  | 36% | 1.83d | 0d |  |  | 16h | 5.8h |
| 37 | 1.1.2.4.1 | Definição funcional da Apresentação dos Resultados | 4h | 2003-08-20 13:00 A | 2003-08-21 11:00 A | 34 | 100% |  |  |  | Gustavo | 4h | 4h |
| 38 | 1.1.2.4.2 | Codificação parte 1 | 9h | 2003-08-21 11:00 A | 2003-08-22 14:00 | 37 | 20% | 7.2h | 0d |  | Gustavo | 9h | 1.8h |
| 39 | 1.1.2.4.3 | Testes de Unidade | 3h | 2003-08-25 08:00 | 2003-08-25 11:00 | 38 |  |  | 0d |  | Gustavo | 3h |  |
| 40 | 1.1.2.5 | **ASP.NET** | 4.38d | 2003-08-20 11:00 A | 2003-08-26 15:00 A |  | 100% |  |  |  |  | 35h | 35h |
| 41 | 1.1.2.5.1 | Parser para ASP.X | 16h | 2003-08-20 11:00 A | 2003-08-22 11:00 A | 20 | 100% |  |  |  | Suzana | 16h | 16h |
| 42 | 1.1.2.5.2 | Testes de Unidade parser | 4h | 2003-08-22 11:00 A | 2003-08-22 16:00 A | 41 | 100% |  |  |  | Suzana | 4h | 4h |
| 43 | 1.1.2.5.3 | [RF023] Contar número de expressões ASPX | 3h | 2003-08-22 16:00 A | 2003-08-25 10:00 A | 42 | 100% |  |  |  | Suzana | 3h | 3h |
| 44 | 1.1.2.5.4 | [RF024] Contar número de invocações de tags pré-definidas e ASP.NET | 3h | 2003-08-25 10:00 A | 2003-08-25 14:00 A | 43 | 100% |  |  |  | Suzana | 3h | 3h |
| 45 | 1.1.2.5.5 | [RF025] Contar número de tags validators | 3h | 2003-08-25 14:00 A | 2003-08-25 17:00 A | 44 | 100% |  |  |  | Suzana | 3h | 3h |
| 46 | 1.1.2.5.6 | [RF026] Contar definições de novas tags ASP.NET | 3h | 2003-08-26 08:00 A | 2003-08-26 11:00 A | 45 | 100% |  |  |  | Suzana | 3h | 3h |
| 47 | 1.1.2.5.7 | Testes de unidade | 3h | 2003-08-26 11:00 A | 2003-08-26 15:00 A | 46 | 100% |  |  |  | Suzana | 3h | 3h |
| 48 | 1.1.2.6 | Projeto de testes | 2h | 2003-08-25 11:00 | 2003-08-25 13:00 | 39 |  |  | 0d |  | Gustavo | 2h |  |
| 49 | 1.1.2.7 | Incremento do projeto (saída+revisão) | 2h | 2003-08-25 13:00 | 2003-08-26 09:00 | 48, 39, 16 |  |  | 0d |  | Andre | 2h |  |
| 50 | 1.1.2.8 | Geração + teste de Release 0.2.0 | 4h | 2003-08-26 09:00 | 2003-08-26 13:00 | 49 |  |  | 0d |  | Andre | 4h |  |
| 51 | 1.1.2.9 | Ajustes Adeline | 4h | 2003-08-26 13:00 | 2003-08-27 11:00 | 50, 27 |  |  | 2.12d | 0d | Adeline | 4h |  |
| 52 | 1.1.2.10 | Ajustes Gustavo | 4h | 2003-08-26 13:00 | 2003-08-27 11:00 | 50, 48 |  |  | 1.25d | 0d | Gustavo | 4h |  |
| 53 | 1.1.2.11 | Ajustes André | 4h | 2003-08-26 13:00 | 2003-08-27 11:00 | 50 |  |  | 0d |  | Andre | 4h |  |
| 54 | 1.1.2.12 | Ajustes Suzana | 4h | 2003-08-26 15:00 | 2003-08-27 10:00 | 50, 47 |  |  | 0.25d | 0d | Suzana | 4h |  |

Notes:
- 32: Falta a informacao da posicao vinda do parser
- 33: Falta a informacao da posicao vinda do parser
- 38: Reallocacao para o parser

| ID | WBS | Task | Duration | Start | Finish | Predecessors | Total slack | Free slack | Constraint | Resources | Work |
| --- | --- | --- | --- | --- | --- | --- | --- | --- | --- | --- | --- |
| 55 | 1.1.3 | **Internal Release 0.3.0** | 3.38d | 2003-08-27 10:00 | 2003-09-01 14:00 |  | 0.12d |  |  |  | 68h |
| 56 | 1.1.3.1 | Descrever Documento do Internal Release | 4h | 2003-08-27 10:00 | 2003-08-27 15:00 | 54 | 0.25d | 0d | start no earlier than 2003-06-18 08:00 | Suzana | 4h |
| 57 | 1.1.3.2 | **Métricas OO** | 1.12d | 2003-08-27 11:00 | 2003-08-28 13:00 |  | 1.62d |  |  |  | 8h |
| 58 | 1.1.3.2.1 | **Codificação** | 0.75d | 2003-08-27 11:00 | 2003-08-28 09:00 |  | 1.38d |  |  |  | 4h |
| 59 | 1.1.3.2.1.1 | [RF018] Abstração | 2.5h | 2003-08-27 11:00 | 2003-08-27 13:30 | 52 | 1.62d | 0d |  | Gustavo | 2.5h |
| 60 | 1.1.3.2.1.2 | [RF019] Número de classes e interfaces por namespace | 1.5h | 2003-08-27 13:30 | 2003-08-28 09:00 | 59 | 1.38d | 0d |  | Gustavo | 1.5h |
| 61 | 1.1.3.2.2 | Testes de Unidade | 4h | 2003-08-28 09:00 | 2003-08-28 13:00 | 60 | 1.38d |  |  | Gustavo | 4h |
| 62 | 1.1.3.3 | **ASP.NET** | 2.38d | 2003-08-27 15:00 | 2003-09-01 09:00 |  | 0.25d |  |  |  | 19h |
| 63 | 1.1.3.3.1 | **Codificação** | 2d | 2003-08-27 15:00 | 2003-08-29 15:00 |  | 0.25d |  |  |  | 16h |
| 64 | 1.1.3.3.1.1 | Parser para ASPX.CS | 10h | 2003-08-27 15:00 | 2003-08-28 17:00 | 56 | 0.25d | 0d |  | Suzana | 10h |
| 65 | 1.1.3.3.1.2 | [RF027] Contar número de eventos ASP.NET | 3h | 2003-08-29 08:00 | 2003-08-29 11:00 | 64 | 0.25d | 0d |  | Suzana | 3h |
| 66 | 1.1.3.3.1.3 | [RF028] Contar número de eventos ASP.NET efetivos | 3h | 2003-08-29 11:00 | 2003-08-29 15:00 | 65 | 0.25d | 0d |  | Suzana | 3h |
| 67 | 1.1.3.3.2 | Testes de Unidade | 3h | 2003-08-29 15:00 | 2003-09-01 09:00 | 66 | 0.25d | 0d |  | Suzana | 3h |
| 68 | 1.1.3.4 | **Visualização dos resultados** | 1.25d | 2003-08-27 11:00 | 2003-08-28 14:00 |  | 0d |  |  |  | 9h |
| 69 | 1.1.3.4.1 | Codificação | 6h | 2003-08-27 11:00 | 2003-08-28 11:00 | 53 | 0d |  |  | Andre | 6h |
| 70 | 1.1.3.4.2 | Testes de Unidade | 3h | 2003-08-28 11:00 | 2003-08-28 14:00 | 69 | 0d |  |  | Andre | 3h |
| 71 | 1.1.3.5 | Projeto de testes Gustavo | 2h | 2003-08-27 11:00 | 2003-08-27 13:00 | 51 | 0.62d | 0d |  | Adeline | 2h |
| 72 | 1.1.3.6 | Projeto de testes André | 2h | 2003-08-27 13:00 | 2003-08-28 09:00 | 71 | 0.38d | 0d |  | Adeline | 2h |
| 73 | 1.1.3.7 | Projeto de testes Suzana | 2h | 2003-08-28 09:00 | 2003-08-28 11:00 | 72 | 0.25d |  |  | Adeline | 2h |
| 74 | 1.1.3.8 | Geração + teste de Release 0.3.0 | 6h | 2003-08-29 08:00 | 2003-08-29 14:00 | 71, 72, 73, 70 | 0d |  |  | Andre | 6h |
| 75 | 1.1.3.9 | Ajustes Adeline | 4h | 2003-09-01 08:00 | 2003-09-01 12:00 | 74 | 0.12d |  |  | Adeline | 4h |
| 76 | 1.1.3.10 | Ajustes Gustavo | 4h | 2003-09-01 08:00 | 2003-09-01 12:00 | 74, 61 | 0.12d |  |  | Gustavo | 4h |
| 77 | 1.1.3.11 | Ajustes Suzana | 4h | 2003-09-01 09:00 | 2003-09-01 14:00 | 74, 67 | 0.25d | 0d |  | Suzana | 4h |
| 78 | 1.1.3.12 | Ajustes André | 4h | 2003-09-01 08:00 | 2003-09-01 12:00 | 74 | 1.12d |  |  | Andre | 4h |

| ID | WBS | Task | Duration | Start | Finish | Predecessors | Total slack | Resources | Work |
| --- | --- | --- | --- | --- | --- | --- | --- | --- | --- |
| 79 | 1.2 | **Estabilização** | 1.62d | 2003-09-01 08:00 | 2003-09-02 14:00 |  | 0d |  | 30h |
| 80 | 1.2.1 | **Internal Release E.1** | 1.62d | 2003-09-01 08:00 | 2003-09-02 14:00 |  | 0d |  | 30h |
| 81 | 1.2.1.1 | Projeto de testes de estabilização | 3h | 2003-09-01 08:00 | 2003-09-01 11:00 | 74 | 0d | Andre | 3h |
| 82 | 1.2.1.2 | Execução dos Testes | 3h | 2003-09-01 11:00 | 2003-09-01 14:00 | 81 | 0d | Andre | 3h |
| 83 | 1.2.1.3 | Ajustes Adeline | 6h | 2003-09-02 08:00 | 2003-09-02 14:00 | 82, 75 | 0d | Adeline | 6h |
| 84 | 1.2.1.4 | Ajustes Gustavo | 6h | 2003-09-02 08:00 | 2003-09-02 14:00 | 82, 76 | 0d | Gustavo | 6h |
| 85 | 1.2.1.5 | Ajustes Suzana | 6h | 2003-09-01 14:00 | 2003-09-02 11:00 | 82, 77 | 0.25d | Suzana | 6h |
| 86 | 1.2.1.6 | Ajustes André | 6h | 2003-09-02 08:00 | 2003-09-02 14:00 | 82 | 0d | Andre | 6h |
